| TaskID | TaskName | StartDate | EndDate | Duration | Progress | DurationUnit | resources | Predecessor |
| --- | --- | --- | --- | --- | --- | --- | --- | --- |
| 1 | FeatherFeed Entwicklung | 2025-05-01T06:00:00.000Z | 2025-06-27T15:00:00.000Z | 42 | 0 | day |  |  |
| 2 | · Grundkonzept überlegen | 2025-05-01T06:00:00.000Z | 2025-05-07T15:00:00.000Z | 5 | 0 | day | Team Member 1 Team Member 1 100 |  |
| 3 | · Figma design erstellen | 2025-05-08T06:00:00.000Z | 2025-05-22T15:00:00.000Z | 11 | 0 | day | Team Member 2 Team Member 2 100 | 2FS |
| 24 | · UI steht | 2025-05-22T15:00:00.000Z | 2025-05-22T15:00:00.000Z | 0 | 0 | day |  | 3FS |
| 23 | · UI implementieren | 2025-05-23T06:00:00.000Z | 2025-06-12T15:00:00.000Z | 15 | 0 | day |  | 24FS |
| 4 | · Basic-UI-Komponenten implementieren | 2025-05-23T06:00:00.000Z | 2025-05-29T15:00:00.000Z | 5 | 0 | day | Team Member 3 Team Member 3 100 | 23SS |
| 10 | · Login / Sign up UI implementieren | 2025-05-27T06:00:00.000Z | 2025-06-03T15:00:00.000Z | 6 | 0 | day |  | 23SS+2 days |
| 12 | · Post Erstellungsseiten UI erstellen | 2025-05-28T06:00:00.000Z | 2025-06-04T15:00:00.000Z | 6 | 0 | day |  | 23SS+3 days |
| 11 | · Feed UI erstellen | 2025-05-29T06:00:00.000Z | 2025-06-06T15:00:00.000Z | 7 | 0 | day |  | 23SS+4 days |
| 13 | · Nutzerprofil UI erstellen | 2025-06-03T06:00:00.000Z | 2025-06-10T15:00:00.000Z | 6 | 0 | day |  | 23SS+7 days |
| 22 | · UI Komponenten fertig | 2025-06-12T15:00:00.000Z | 2025-06-12T15:00:00.000Z | 0 | 0 | day |  | 23FS |
| 14 | · Backend planen | 2025-05-08T06:00:00.000Z | 2025-05-14T15:00:00.000Z | 5 | 0 | day |  | 2FS |
| 15 | · Datenbank aufsetzen | 2025-05-15T06:00:00.000Z | 2025-05-21T15:00:00.000Z | 5 | 0 | day |  | 14FS |
| 16 | · Authentifizierung einrichten | 2025-05-22T06:00:00.000Z | 2025-05-30T15:00:00.000Z | 7 | 0 | day |  | 15FS |
| 17 | · Endpunkte erstellen | 2025-06-02T06:00:00.000Z | 2025-06-11T15:00:00.000Z | 8 | 0 | day |  | 16FS |
| 6 | · Backend steht | 2025-06-12T15:00:00.000Z | 2025-06-12T15:00:00.000Z | 0 | 0 | day |  | 17FS,22FS |
| 25 | · Verbindung mit Backend herstellen | 2025-06-13T06:00:00.000Z | 2025-06-27T15:00:00.000Z | 11 | 0 | day |  | 6FS |
| 18 | · Login mit Backend verbinden | 2025-06-13T06:00:00.000Z | 2025-06-18T15:00:00.000Z | 4 | 0 | day |  | 25SS |
| 21 | · Nutzerprofil UI mit Backend verbinden | 2025-06-17T06:00:00.000Z | 2025-06-20T15:00:00.000Z | 4 | 0 | day |  | 25SS+2 days |
| 19 | · Post Erstellungsseite mit Backend verbinden | 2025-06-18T06:00:00.000Z | 2025-06-24T15:00:00.000Z | 5 | 0 | day |  | 25SS+3 days |
| 20 | · Feed UI mit Backend verbinden | 2025-06-20T06:00:00.000Z | 2025-06-26T15:00:00.000Z | 5 | 0 | day |  | 25SS+5 days |
| 7 | · Webseite funktionsfähig | 2025-06-27T15:00:00.000Z | 2025-06-27T15:00:00.000Z | 0 | 0 | day |  | 25FS |

Links (from, to):
- 8 12
- 13 17
